# Projekt_jo_02_03

How a schedule from MS Project changed from version to version. A marks actual dates.

## Version 1 (data date 2008-08-29, saved 2008-06-30, file Projekt_06_alap.mpp)

| ID | WBS | Task | Duration | Start | Finish | Predecessors | Total float |
| --- | --- | --- | --- | --- | --- | --- | --- |
| 1 | 1 | **Célmeghatározás** | 7.5d | 2008-10-27 | 2008-11-05 |  | 0d |
| 2 |  | Projektindító értekezlet | 1d | 2008-10-27 | 2008-10-27 |  | 141d |
| 3 |  | Tárolandó dokumentumtípusok megismerése | 3d | 2008-10-28 | 2008-10-30 | 2 | 142d |
| 4 |  | Jelenlegi dokumentumkezelési eljárások megismerése | 2d | 2008-10-31 | 2008-11-03 | 3 | 142d |
| 5 |  | Az új rendszerrel szemben támasztott követelmények összeállítása | 6d | 2008-10-28 | 2008-11-04 | 2 | 141d |
| 6 |  | Megbízó oldali céldokumentum kész | 0d | 2008-11-04 | 2008-11-04 | 5 | 141d |
| 7 |  | Eredmények ismertetése | 4h | 2008-11-05 | 2008-11-05 | 6, 4 | 141d |
| 8 |  | Az IT oldal javaslata az új rendszer specifikációjához | 4d | 2008-10-27 | 2008-10-30 |  | 144.5d |
| 9 |  | IT oldali céldokumentum megvitatása | 4h | 2008-10-27 | 2008-10-27 |  | 0d |
| 10 |  | Módosítások elkészítése | 1d | 2008-10-27 | 2008-10-28 | 9 | 0d |
| 11 |  | Céldokumentum elfogadása | 0d | 2008-10-28 | 2008-10-28 | 10 | 0d |
| 12 | 2 | **Tervezés** | 13d | 2008-10-28 | 2008-11-14 |  | 0d |
| 13 |  | Üzemeltetési jellemzők kidolgozása | 6d | 2008-10-28 | 2008-11-05 | 11 | 0d |
| 14 |  | Prototípus kidolgozása az üzemeltetési jellemzők alapján | 4d | 2008-11-05 | 2008-11-11 | 13 | 0d |
| 15 |  | Funkcionális specifikációk áttekintése | 3d | 2008-11-11 | 2008-11-14 | 14 | 0d |
| 16 |  | Döntés a továbblépésről | 0d | 2008-11-14 | 2008-11-14 | 15 | 0d |
| 17 |  | Tervezés kész | 0d | 2008-11-14 | 2008-11-14 | 16 | 0d |
| 18 | 3 | **Fejlesztés** | 26d | 2008-11-14 | 2008-12-22 |  | 0d |
| 19 |  | Fejlesztés | 26d | 2008-11-14 | 2008-12-22 | 17 | 0d |
| 20 | 4 | **Tesztelés** | 60d | 2008-11-14 | 2009-02-06 |  | 0d |
| 21 |  | Tesztelés | 60d | 2008-11-14 | 2009-02-06 | 19SS | 0d |
| 22 | 5 | **Dokumentáció** | 25d | 2009-01-21 | 2009-02-25 |  | 31d |
| 23 |  | Dokumentáció készítése | 25d | 2009-01-21 | 2009-02-25 | 21FS-12d, 19 | 31d |
| 24 | 6 | **Próba** | 40d | 2009-02-06 | 2009-04-03 |  | 0d |
| 25 |  | Próbaüzem | 40d | 2009-02-06 | 2009-04-03 | 21 | 0d |
| 26 | 7 | **Telepítés** | 4d | 2009-04-03 | 2009-04-09 |  | 0d |
| 27 |  | Telepítés | 4d | 2009-04-03 | 2009-04-09 | 25 | 0d |
| 28 | 8 | **Továbbképzés** | 30d | 2009-04-09 | 2009-05-21 |  | 0d |
| 29 |  | Továbbképzés | 30d | 2009-04-09 | 2009-05-21 | 27, 23 | 0d |

## Version 2 (data date 2008-11-07, saved 2008-07-07, file Projekt_07_alap.mpp)

Last finish 2009-05-21 → 2009-04-30 (-21d).

Added:

| ID | Task | Duration | Start | Finish | Predecessors | Resources |
| --- | --- | --- | --- | --- | --- | --- |
| 8 | felhasználói interjúk készítése | 8d | 2008-11-06 | 2008-11-17 | 7FS+0.5d | Á műszaki informatikus 1; Á műszaki informatikus 2; Egyéb költségek [67 eFt] |
| 9 | felhasználói interjúk kiértékelése | 2d | 2008-11-07 | 2008-11-11 | 8SS+1.5d | Á műszaki informatikus 1 |
| 11 | IT oldali céldokumentum kész | 0d | 2008-11-21 | 2008-11-21 | 10 |  |
| 22 | Funkcionális specifikációk áttekintése | 1d | 2008-12-12 | 2008-12-15 | 20 | Á programozó 1; Á programozó 2; Á programozó 3; Á programozó 4 |
| 23 | Moduláris vagy réteges tervparaméterek azonosítása | 1d | 2008-12-15 | 2008-12-16 | 22 | Á programozó 1; Á programozó 2 |
| 24 | Fejlesztőgárda hozzárendelése | 1d | 2008-12-16 | 2008-12-17 | 23 | Á programozó 1; Á programozó 2; Á programozó 3; Á programozó 4; Á_projektmenedzser |

Removed: 19 Fejlesztés

Changed:

| ID | Task | Start | Finish | Duration | Total float | Predecessors | Other |
| --- | --- | --- | --- | --- | --- | --- | --- |
| 1 | **Célmeghatározás** |  | 2008-11-05 → 2008-11-25 (+20d) | 7.5d → 21.5d | 0d → 96.5d |  |  |
| 5 | Az új rendszerrel szemben támasztott követelmények összeállítása |  |  |  | 141d → 96.5d |  | resources Á megbízó koordinátor 1; Á megbízó koordinátor 2 → Nyári Éva; Á megbízó koordinátor 2 |
| 10 | Az IT oldal javaslata az új rendszer specifikációjához | 2008-10-27 → 2008-11-18 (+22d) | 2008-10-30 → 2008-11-21 (+22d) |  | 144.5d → 96.5d | none → 9, 8 |  |
| 12 | IT oldali céldokumentum megvitatása | 2008-10-27 → 2008-11-24 (+28d) | 2008-10-27 → 2008-11-24 (+28d) |  | 0d → 96.5d | none → 11 |  |
| 13 | Módosítások elkészítése | 2008-10-27 → 2008-11-24 (+28d) | 2008-10-28 → 2008-11-25 (+28d) |  | 0d → 96.5d |  |  |
| 14 | Céldokumentum elfogadása | 2008-10-28 → 2008-11-25 (+28d) | 2008-10-28 → 2008-11-25 (+28d) |  | 0d → 96.5d |  |  |
| 15 | **Tervezés** | 2008-10-28 → 2008-11-25 (+28d) | 2008-11-14 → 2008-12-12 (+28d) |  | 0d → 96.5d |  |  |
| 16 | Üzemeltetési jellemzők kidolgozása | 2008-10-28 → 2008-11-25 (+28d) | 2008-11-05 → 2008-12-03 (+28d) |  | 0d → 96.5d |  |  |
| 17 | Prototípus kidolgozása az üzemeltetési jellemzők alapján | 2008-11-05 → 2008-12-03 (+28d) | 2008-11-11 → 2008-12-09 (+28d) |  | 0d → 96.5d |  |  |
| 18 | Funkcionális specifikációk áttekintése | 2008-11-11 → 2008-12-09 (+28d) | 2008-11-14 → 2008-12-12 (+28d) |  | 0d → 96.5d |  |  |
| 19 | Döntés a továbblépésről | 2008-11-14 → 2008-12-12 (+28d) | 2008-11-14 → 2008-12-12 (+28d) |  | 0d → 96.5d |  |  |
| 20 | Tervezés kész | 2008-11-14 → 2008-12-12 (+28d) | 2008-11-14 → 2008-12-12 (+28d) |  | 0d → 96.5d |  |  |
| 21 | **Fejlesztés** | 2008-11-14 → 2008-12-12 (+28d) | 2008-12-22 → 2008-12-17 (-5d) | 26d → 3d | 0d → 96.5d |  |  |
| 25 | **Tesztelés** | 2008-11-14 → 2008-10-27 (-18d) | 2009-02-06 → 2009-01-16 (-21d) |  |  |  |  |
| 26 | Tesztelés | 2008-11-14 → 2008-10-27 (-18d) | 2009-02-06 → 2009-01-16 (-21d) |  |  | FejlesztésSS → none |  |
| 27 | **Dokumentáció** | 2009-01-21 → 2009-01-01 (-20d) | 2009-02-25 → 2009-02-04 (-21d) |  |  |  |  |
| 28 | Dokumentáció készítése | 2009-01-21 → 2009-01-01 (-20d) | 2009-02-25 → 2009-02-04 (-21d) |  |  | 26FS-12d, Fejlesztés → 26FS-12d |  |
| 29 | **Próba** | 2009-02-06 → 2009-01-19 (-18d) | 2009-04-03 → 2009-03-13 (-21d) |  |  |  |  |
| 30 | Próbaüzem | 2009-02-06 → 2009-01-19 (-18d) | 2009-04-03 → 2009-03-13 (-21d) |  |  |  |  |
| 31 | **Telepítés** | 2009-04-03 → 2009-03-16 (-18d) | 2009-04-09 → 2009-03-19 (-21d) |  |  |  |  |
| 32 | Telepítés | 2009-04-03 → 2009-03-16 (-18d) | 2009-04-09 → 2009-03-19 (-21d) |  |  |  |  |
| 33 | **Továbbképzés** | 2009-04-09 → 2009-03-20 (-20d) | 2009-05-21 → 2009-04-30 (-21d) |  |  |  |  |
| 34 | Továbbképzés | 2009-04-09 → 2009-03-20 (-20d) | 2009-05-21 → 2009-04-30 (-21d) |  |  |  |  |
