# Projekt_jo_02_03

How a schedule from MS Project changed from version to version. A marks actual dates.

## Version 1 (data date 2008-08-29, saved 2008-06-11, file Projekt_05_alap.mpp)

| ID | WBS | Task | Duration | Start | Finish | Predecessors | Total float |
| --- | --- | --- | --- | --- | --- | --- | --- |
| 1 |  | Célmeghatározás | 6.5d | 2008-10-27 | 2008-11-04 |  | 0d |
| 2 |  | Hálózatfejlesztés | 11d | 2008-11-04 | 2008-11-19 | 1 | 0d |
| 3 | 3 | **Betanítás** | 13d | 2008-11-12 | 2008-12-01 |  | 5d |
| 4 | 3.1 | **oktatók felkészítése** | 4d | 2008-11-12 | 2008-11-18 |  | 16d |
| 5 |  | oktatók betanítása | 4d | 2008-11-12 | 2008-11-18 | 2SS+6d | 16d |
| 6 | 3.2 | **Minőségbiztosítás részleg betanítása** | 8d | 2008-11-19 | 2008-12-01 |  | 0d |
| 7 |  | csoport 1. | 2d | 2008-11-19 | 2008-11-21 | 2 | 0d |
| 8 |  | csoport 2. | 3d | 2008-11-21 | 2008-11-26 | 7 | 7d |
| 9 |  | csoport 3. | 3d | 2008-11-26 | 2008-12-01 | 8 | 7d |
| 10 |  | csoport 1. | 3d | 2008-11-21 | 2008-11-26 | 7 | 0d |
| 11 |  | csoport 2. | 3d | 2008-11-26 | 2008-12-01 | 10 | 7d |
| 12 | 3.3 | **Karbantartási részleg betanítása** | 2d | 2008-11-19 | 2008-11-21 |  | 7d |
| 13 |  | csoport 1. | 2d | 2008-11-19 | 2008-11-21 | 7SS | 7d |
| 14 |  | csoport 1. | 2d | 2008-11-19 | 2008-11-21 | 7SS | 7d |
| 15 | 4 | **Adatfeltöltés** | 15d | 2008-11-19 | 2008-12-10 |  | 0d |
| 16 | 4.1 | **Minőségbiztosítási részleg adatfeltöltés** | 15d | 2008-11-19 | 2008-12-10 |  | 0d |
| 17 |  | adatfeltöltés | 12d | 2008-11-19 | 2008-12-05 | 7SS, 9FF-3d | 3d |
| 18 |  | adatfeltöltés | 10d | 2008-11-26 | 2008-12-10 | 10, 11FF-2d | 0d |
| 19 | 4.2 | **Karbantartási részleg adatfeltöltés** | 13d | 2008-11-21 | 2008-12-10 |  | 0d |
| 20 |  | adatfeltöltés | 6d | 2008-11-21 | 2008-12-01 | 13 | 7d |
| 21 |  | adatfeltöltés | 6d | 2008-11-21 | 2008-12-01 | 14 | 7d |
| 22 |  | adatfeltöltés kész | 0d | 2008-12-10 | 2008-12-10 | 17, 18, 20, 21 | 0d |

## Version 2 (data date 2008-11-21, saved 2008-11-26, file prproba.mpp)

Last finish 2008-12-10 → 2008-12-29 (+19d). Complete tasks 0 → 3.

Added:

| ID | Task | Duration | Start | Finish | Predecessors | Constraint | Resources |
| --- | --- | --- | --- | --- | --- | --- | --- |
| 6 | Program tesztelése | 6d | 2008-11-24 | 2008-12-02 | 5SS+1d | start no earlier than 2008-11-24 | László Róbert; Á oktató 1 [50%]; Á oktató 2 [50%]; Á oktató 3 [50%] |
| 7 | Látszat | 0d | 2008-12-03 | 2008-12-03 | 6FF+1d | start no earlier than 2008-11-24 |  |
| 8 | Jegyzet készítése | 8d | 2008-11-26 | 2008-12-08 | 6SS+2d, 7FF, 5 | start no earlier than 2008-11-24 |  |
| 9 | Felkészítés kész | 1d? | 2008-12-08 | 2008-12-09 | 8 | start no earlier than 2008-11-24 |  |

Changed:

| ID | Task | Start | Finish | Duration | Complete | Total float | Predecessors | Other |
| --- | --- | --- | --- | --- | --- | --- | --- | --- |
| 1 | Célmeghatározás | 2008-10-27 A | 2008-11-04 A |  | 0% → 100% | 0d → none |  | baseline start none → 2008-10-27; baseline finish none → 2008-11-04 |
| 2 | Hálózatfejlesztés | 2008-11-04 A | 2008-11-19 → 2008-11-17 A (-2d) | 11d → 9d | 0% → 100% | 0d → none |  | baseline start none → 2008-11-04; baseline finish none → 2008-11-17 |
| 3 | **Betanítás** | 2008-11-12 A | 2008-12-01 → 2008-12-19 (+18d) | 13d → 26.62d? | 0% → 11% | 5d → 6.76d |  | baseline start none → 2008-11-12; baseline finish none → 2008-12-11 |
| 4 | **oktatók felkészítése** | 2008-11-12 A | 2008-11-18 → 2008-12-09 (+21d) | 4d → 18.62d? | 0% → 21% | 16d → -1.12d |  | baseline start none → 2008-11-12; baseline finish none → 2008-12-01 |
| 5 | oktatók betanítása | 2008-11-12 A | 2008-11-18 A |  | 0% → 100% | 16d → none |  | resources Á oktató 1 [50%]; Á oktató 2 [50%]; Á oktató 3 [50%]; Baumgartner Karina → Á oktató 1 [62.5%]; Á oktató 2 [62.5%]; Á oktató 3 [62.5%]; Kőpataki Tihamér [62.5%]; baseline start none → 2008-11-12; baseline finish none → 2008-11-18 |
| 10 | **Minőségbiztosítás részleg betanítása** | 2008-11-19 → 2008-12-09 (+20d) | 2008-12-01 → 2008-12-19 (+18d) |  |  |  |  | baseline start none → 2008-12-01; baseline finish none → 2008-12-11 |
| 11 | csoport 1. | 2008-11-19 → 2008-12-09 (+20d) | 2008-11-21 → 2008-12-11 (+20d) |  |  |  | 2 → 2, 9 | constraint none → start no earlier than 2008-11-24; baseline start none → 2008-12-01; baseline finish none → 2008-12-03 |
| 12 | csoport 2. | 2008-11-21 → 2008-12-11 (+20d) | 2008-11-26 → 2008-12-16 (+20d) |  |  | 7d → 6.76d |  | constraint none → start no earlier than 2008-11-24; baseline start none → 2008-12-03; baseline finish none → 2008-12-08 |
| 13 | csoport 3. | 2008-11-26 → 2008-12-16 (+20d) | 2008-12-01 → 2008-12-19 (+18d) |  |  | 7d → 6.76d |  | constraint none → start no earlier than 2008-11-24; baseline start none → 2008-12-08; baseline finish none → 2008-12-11 |
| 14 | csoport 1. | 2008-11-21 → 2008-12-11 (+20d) | 2008-11-26 → 2008-12-16 (+20d) |  |  |  |  | constraint none → start no earlier than 2008-11-24; baseline start none → 2008-12-03; baseline finish none → 2008-12-08 |
| 15 | csoport 2. | 2008-11-26 → 2008-12-16 (+20d) | 2008-12-01 → 2008-12-19 (+18d) |  |  | 7d → 6.76d |  | constraint none → start no earlier than 2008-11-24; baseline start none → 2008-12-08; baseline finish none → 2008-12-11 |
| 16 | **Karbantartási részleg betanítása** | 2008-11-19 → 2008-12-09 (+20d) | 2008-11-21 → 2008-12-11 (+20d) |  |  | 7d → 6.76d |  | baseline start none → 2008-12-01; baseline finish none → 2008-12-03 |
| 17 | csoport 1. | 2008-11-19 → 2008-12-09 (+20d) | 2008-11-21 → 2008-12-11 (+20d) |  |  | 7d → 6.76d |  | constraint none → start no earlier than 2008-11-24; baseline start none → 2008-12-01; baseline finish none → 2008-12-03 |
| 18 | csoport 1. | 2008-11-19 → 2008-12-09 (+20d) | 2008-11-21 → 2008-12-11 (+20d) |  |  | 7d → 6.76d |  | constraint none → start no earlier than 2008-11-24; baseline start none → 2008-12-01; baseline finish none → 2008-12-03 |
| 19 | **Adatfeltöltés** | 2008-11-19 → 2008-12-09 (+20d) | 2008-12-10 → 2008-12-29 (+19d) | 15d → 14.76d |  |  |  | baseline start none → 2008-12-01; baseline finish none → 2008-12-22 |
| 20 | **Minőségbiztosítási részleg adatfeltöltés** | 2008-11-19 → 2008-12-09 (+20d) | 2008-12-10 → 2008-12-29 (+19d) | 15d → 14.76d |  |  |  | baseline start none → 2008-12-01; baseline finish none → 2008-12-22 |
| 21 | adatfeltöltés | 2008-11-19 → 2008-12-09 (+20d) | 2008-12-05 → 2008-12-25 (+20d) |  |  | 3d → 2.76d |  | baseline start none → 2008-12-01; baseline finish none → 2008-12-17 |
| 22 | adatfeltöltés | 2008-11-26 → 2008-12-16 (+20d) | 2008-12-10 → 2008-12-29 (+19d) | 10d → 9.76d |  |  |  | resources Á műszaki informatikus 2; Á műszaki informatikus 3 → Á műszaki informatikus 3 [200%]; Á műszaki informatikus 4; baseline start none → 2008-12-08; baseline finish none → 2008-12-22 |
| 23 | **Karbantartási részleg adatfeltöltés** | 2008-11-21 → 2008-12-11 (+20d) | 2008-12-10 → 2008-12-29 (+19d) | 13d → 12.76d |  |  |  | baseline start none → 2008-12-03; baseline finish none → 2008-12-22 |
| 24 | adatfeltöltés | 2008-11-21 → 2008-12-11 (+20d) | 2008-12-01 → 2008-12-19 (+18d) |  |  | 7d → 6.76d |  | baseline start none → 2008-12-03; baseline finish none → 2008-12-11 |
| 25 | adatfeltöltés | 2008-11-21 → 2008-12-11 (+20d) | 2008-12-01 → 2008-12-19 (+18d) |  |  | 7d → 6.76d |  | baseline start none → 2008-12-03; baseline finish none → 2008-12-11 |
| 26 | adatfeltöltés kész | 2008-12-10 → 2008-12-29 (+19d) | 2008-12-10 → 2008-12-29 (+19d) |  |  |  |  | baseline start none → 2008-12-22; baseline finish none → 2008-12-22 |
